# bcsg2

Schedule from MS Project, 2001-12-03 to 2002-12-27.
CERN

## Calendars

- Standard: Mon-Fri 08:00-12:00, 13:00-17:00; Sat-Sun off.

## Resources

| Resource |
| --- |
| JBJ |
| BCSG |
| MH |
| RA |
| BI |
| DK |
| JW |
| ML |
| FS |
| MB |
| TIS |
| DB |
| LV |
| VK |
| RS |
| IB |
| ??? |
| BD |
| EG |
| HB |
| JB |
| GB |
| CF |
| RJ |
| all |
| YL? |
| LY? |
| AV? |
| AV |
| IB? |
| FS? |

## Schedule

| ID | Task | Duration | Start | Finish | Total slack | Constraint | Resources | Work |
| --- | --- | --- | --- | --- | --- | --- | --- | --- |
| 1 | Additional tools for tracking with collimators and imperfections | 107d? | 2001-12-03 | 2002-04-30 | 153d | start no earlier than 2001-12-03 | RA; DK | 1712h |
| 2 | Irregular beam loss and failure scenarios | 107d? | 2001-12-03 | 2002-04-30 | 153d | start no earlier than 2001-12-03 | VK; RS; RA | 2568h |
| 3 | Showering studies and heat maps | 107d? | 2001-12-03 | 2002-04-30 | 173d | start no earlier than 2001-12-03 | JBJ; IB? | 1712h |
| 4 | BLM studies for the old system | 110d? | 2001-12-03 | 2002-05-03 | 169d | start no earlier than 2001-12-03 | BD; EG; JBJ | 880h |
| 5 | Analysis of asynchronous firing of beam dump | 32d? | 2001-12-03 | 2002-01-15 | 247d | start no earlier than 2001-12-03 | JBJ | 256h |
| 6 | Expected beam loss during injection (oscillations) | 32d? | 2001-12-03 | 2002-01-15 | 247d | start no earlier than 2001-12-03 | HB | 256h |
| 7 | Dynamic effects during ramp and squeeze | 64d? | 2001-12-03 | 2002-02-28 | 215d | start no earlier than 2001-12-03 | MH; RA | 1024h |
| 8 | Insertion design with longer collimators | 42.67d? | 2001-12-03 | 2002-01-30 | 237.33d | start no earlier than 2001-12-03 | DK; JBJ; AV? | 1024h |
| 9 | Orbit stability during ramp and squeeze | 64d? | 2001-12-03 | 2002-02-28 | 215d | start no earlier than 2001-12-03 | JW | 512h |
| 10 | Move beam instead of collimators? Possible? Implications? | 64d? | 2001-12-03 | 2002-02-28 | 216d | start no earlier than 2001-12-03 | JW | 512h |
| 11 | Impact of showers on BPM accuracy in collimation region | 64d? | 2001-12-03 | 2002-02-28 | 216d | start no earlier than 2001-12-03 | BD | 512h |
| 12 | Operational constraints on collimator design | 64d? | 2001-12-03 | 2002-02-28 | 216d | start no earlier than 2001-12-03 | ML | 512h |
| 13 | RF timing failures | 130d? | 2001-12-03 | 2002-05-31 | 150d | start no earlier than 2001-12-03 | ??? | 1040h |
| 14 | Beam loss due to RF ripple | 130d? | 2001-12-03 | 2002-05-31 | 150d | start no earlier than 2001-12-03 | ??? | 1040h |
| 15 | Discarding protons in the abort gap | 130d? | 2001-12-03 | 2002-05-31 | 150d | start no earlier than 2001-12-03 | RS | 1040h |
| 16 | Halo population and diffusion speed | 86.67d? | 2001-12-03 | 2002-04-02 | 193.33d | start no earlier than 2001-12-03 | LY?; FS?; RA | 2080h |
| 17 | Collimator specifications based on expected beam losses | 35d? | 2001-12-03 | 2002-01-18 | 245d | start no earlier than 2001-12-03 | all | 280h |
| 18 | Set-up of tools for damage prediction | 24d? | 2002-01-01 | 2002-02-01 | 235d | start no earlier than 2002-01-01 | ??? | 192h |
| 19 | CERN meeting on Collimators and Beam absorbers | 2d? | 2002-01-23 | 2002-01-24 | 241d | start no earlier than 2002-01-23 | all | 16h |
| 20 | Conceptual design of an improved collimation system | 25d? | 2002-01-25 | 2002-02-28 | 216d | start no earlier than 2002-01-25 | all | 200h |
| 21 | Radiological aspects and constraints | 46d? | 2002-01-25 | 2002-03-29 | 195d | start no earlier than 2002-01-25 | MB | 368h |
| 22 | Prediction of collimator heating | 45d? | 2002-01-28 | 2002-03-29 | 195d | start no earlier than 2002-01-27 | IB?; MB; JBJ | 1080h |
| 23 | Prediction of collimator damage | 41d? | 2002-02-01 | 2002-03-29 | 195d | start no earlier than 2002-02-01 | ??? | 328h |
| 24 | Impedance constraints | 15d? | 2002-02-08 | 2002-02-28 | 216d | start no earlier than 2002-02-08 | DB; LV; JBJ | 360h |
| 25 | Matching and re-design of cleaning insertions | 28.67d? | 2002-03-01 | 2002-04-10 | 187.33d | start no earlier than 2002-03-01 | DK; JBJ; AV? | 688h |
| 26 | First technical design of improved collimators | 65d? | 2002-03-01 | 2002-05-30 | 151d | start no earlier than 2002-03-01 | GB; CF; RJ | 1560h |
| 27 | Impedance review | 20d? | 2002-06-03 | 2002-06-28 | 130d | start no earlier than 2002-06-03 | DB; LV; JBJ | 480h |
| 28 | Cleaning efficiency for the new system | 133d? | 2002-05-01 | 2002-11-01 | 40d | start no earlier than 2002-05-01 | RA; DK | 2128h |
| 29 | Detailed prediction of activation in cleaning insertions | 133d? | 2002-05-01 | 2002-11-01 | 40d | start no earlier than 2002-05-01 | MB; IB? | 2128h |
| 30 | Response of new collimation to irregular beam loss and failures | 135d? | 2002-04-29 | 2002-11-01 | 40d | start no earlier than 2002-04-28 | VK; RS; RA | 3240h |
| 31 | Operation with the new system | 132d? | 2002-05-01 | 2002-10-31 | 41d | start no earlier than 2002-05-01 | ML; JW; RA | 3168h |
| 32 | Use of quadrupolar BPM's | 75d? | 2002-04-29 | 2002-08-09 | 100d | start no earlier than 2002-04-28 | BD | 600h |
| 33 | Showering in the new collimator system | 75.33d? | 2002-05-01 | 2002-08-14 | 97.67d | start no earlier than 2002-05-01 | JBJ; MB; IB? | 1808h |
| 34 | Beam loss monitor signals | 109d? | 2002-06-03 | 2002-10-31 | 41d | start no earlier than 2002-06-03 | BD; EG | 1744h |
| 35 | Detailed design of collimators (incl feedback from detailed studies) | 109d? | 2002-06-03 | 2002-10-31 | 41d | start no earlier than 2002-06-03 | GB; CF; RJ | 2616h |
| 36 | Experimental tests of collimator design | 85d? | 2002-06-03 | 2002-09-27 | 65d | start no earlier than 2002-06-02 | GB; CF; RJ; RA | 2720h |
| 37 | Impedance review | 21d? | 2002-11-01 | 2002-11-29 | 20d | start no earlier than 2002-11-01 | DB; LV; JBJ | 504h |
| 38 | Use of crystals | 224d? | 2002-02-18 | 2002-12-26 | 1d | start no earlier than 2002-02-17 | ??? | 1792h |
| 39 | Machine experiments | 224d? | 2002-02-18 | 2002-12-26 | 1d | start no earlier than 2002-02-17 | RA; JBJ | 3584h |
| 40 | Catastrophic beam loss scenario | 224d? | 2002-02-18 | 2002-12-26 | 1d | start no earlier than 2002-02-17 | ??? | 1792h |
| 41 | Measure tertiary halo in collimation section directly | 225d? | 2002-02-18 | 2002-12-27 | 0d | start no earlier than 2002-02-17 | ??? | 1800h |
